# EyeRIS Development

Schedule from GanttProject, 2019-03-01 to 2019-09-05.
MBARI
Development of plenoptic imaging systems for ROVs and AUVs
Holidays every year on 01-01, 07-04, 11-11, 12-25

## Calendars

- Project calendar: Mon-Fri working; Sat-Sun off. Exceptions (off unless hours are given): 2019-05-27 (Memorial Day), 2019-09-02 (Labor Day).

## Resources

| Resource |
| --- |
| Paul Roberts |
| Denis Klimov |
| Jon Erickson |
| Rich Henthorn |
| Tom Marion |
| Frank Flores |
| Alana Sherman |
| Henry Ruhl |
| Kakani Katija |

## Schedule

| ID | WBS | Task | Type | Duration | Start | Finish | Predecessors |
| --- | --- | --- | --- | --- | --- | --- | --- |
| 1 | 1 | **EyeRIS Cabled Instrument Development** |  | 132d | 2019-03-01 | 2019-09-05 |  |
| 2 | 1.1 | Concept Design |  | 5d | 2019-03-01 | 2019-03-07 |  |
| 3 | 1.2 | Concept Review | milestone | 0d | 2019-03-08 | 2019-03-08 | 2 |
| 4 | 1.3 | **Design** |  | 14d | 2019-03-08 | 2019-03-27 | 3 |
| 5 | 1.3.1 | **Mechanical** |  | 14d | 2019-03-08 | 2019-03-27 |  |
| 6 | 1.3.1.1 | Housings |  | 7d | 2019-03-08 | 2019-03-18 |  |
| 7 | 1.3.1.2 | Internal Fixtures |  | 7d | 2019-03-08 | 2019-03-18 |  |
| 8 | 1.3.1.3 | Light Fixture |  | 7d | 2019-03-19 | 2019-03-27 | 7 |
| 9 | 1.3.1.4 | ROV Mounting |  | 7d | 2019-03-19 | 2019-03-27 | 6 |
| 10 | 1.3.2 | **Optical** |  | 11d | 2019-03-08 | 2019-03-22 |  |
| 11 | 1.3.2.1 | Lens Selection |  | 4d | 2019-03-08 | 2019-03-13 |  |
| 12 | 1.3.2.2 | Imaging Geometry |  | 7d | 2019-03-14 | 2019-03-22 | 11 |
| 13 | 1.3.3 | **Electrical** |  | 13d | 2019-03-08 | 2019-03-26 |  |
| 14 | 1.3.3.1 | Copper<-->Fiber |  | 3d | 2019-03-08 | 2019-03-12 |  |
| 15 | 1.3.3.2 | Control Board |  | 10d | 2019-03-13 | 2019-03-26 | 14 |
| 16 | 1.3.4 | **Software** |  | 7d | 2019-03-08 | 2019-03-18 |  |
| 17 | 1.3.4.1 | Control Board Firmware |  | 7d | 2019-03-08 | 2019-03-18 |  |
| 18 | 1.4 | Design Review | milestone | 0d | 2019-03-28 | 2019-03-28 | 4 |
| 19 | 1.5 | **Development** |  | 91d | 2019-03-28 | 2019-08-05 | 18 |
| 20 | 1.5.1 | **Mechanical** |  | 69d | 2019-03-28 | 2019-07-03 |  |
| 21 | 1.5.1.1 | Cables&Conns |  | 69d | 2019-03-28 | 2019-07-03 |  |
| 22 | 1.5.1.2 | Housing Fabrication |  | 15d | 2019-03-28 | 2019-04-17 |  |
| 23 | 1.5.1.3 | Light Fixture Fabrication |  | 14d | 2019-04-18 | 2019-05-07 | 22 |
| 24 | 1.5.2 | **Electrical** |  | 63d | 2019-03-28 | 2019-06-25 |  |
| 25 | 1.5.2.1 | Copper<-->Fiber Parts |  | 56d | 2019-03-28 | 2019-06-14 |  |
| 26 | 1.5.2.2 | Copper<->Fiber Assembly and Testing |  | 7d | 2019-06-17 | 2019-06-25 | 25 |

| ID | WBS | Task | Type | Duration | Start | Finish | Predecessors |
| --- | --- | --- | --- | --- | --- | --- | --- |
| 27 | 1.5.3 | **System Integration** |  | 15d | 2019-07-05 | 2019-07-25 | 21 |
| 28 | 1.5.3.1 | Camera Internal Assembly |  | 10d | 2019-07-05 | 2019-07-18 |  |
| 29 | 1.5.3.2 | Light Fixture Asseembly |  | 10d | 2019-07-05 | 2019-07-18 |  |
| 30 | 1.5.3.3 | MiniROV Testing |  | 1d | 2019-07-19 | 2019-07-19 | 29 |
| 31 | 1.5.3.4 | Ventana |  | 2d | 2019-07-22 | 2019-07-23 | 30 |
| 32 | 1.5.3.5 | Doc Ricketts |  | 2d | 2019-07-24 | 2019-07-25 | 31 |
| 33 | 1.5.4 | Tank Demo on MiniROV | milestone | 0d | 2019-07-26 | 2019-07-26 | 27 |
| 34 | 1.5.5 | Tank Tests on MiniROV |  | 7d | 2019-07-26 | 2019-08-05 | 33 |
| 35 | 1.6 | **Field Work** |  | 22d | 2019-08-06 | 2019-09-05 | 19 |
| 36 | 1.6.1 | Field Testing on ROV(s) |  | 22d | 2019-08-06 | 2019-09-05 |  |
